# pm01ws02CharityGolfTournament

Schedule from MS Project, 2016-02-11 to 2016-06-01, scheduled back from the finish.
Madison College

## Calendars

- Standard: Mon off; Tue-Fri 08:00-12:00; Sat-Sun off. Exceptions (off unless hours are given): 2016-03-24 to 2016-03-25 (Spring break).

## Schedule

| ID | Task | Type | Duration | Start | Finish | Predecessors | Total slack | Free slack | Constraint |
| --- | --- | --- | --- | --- | --- | --- | --- | --- | --- |
| 1 | Set tournament objectives |  | 4h | 2016-02-11 | 2016-02-12 |  | 0d |  | as late as possible |
| 2 | Set tournament date and time |  | 4h | 2016-02-12 | 2016-02-16 | 1 | 0d |  | as late as possible |
| 3 | Prepare preliminary budget |  | 6h | 2016-02-16 | 2016-02-17 | 2 | 0d |  | as late as possible |
| 4 | Perform site inspections |  | 4h | 2016-02-16 | 2016-02-17 | 3SS | 0d |  | as late as possible |
| 5 | Reserve golf course | milestone | 0d | 2016-02-17 | 2016-02-17 | 4 | 34.25d |  |  |
| 6 | Solicit potential tournament sponsors |  | 1w | 2016-02-16 | 2016-03-03 | 2 | 0d |  | as late as possible |
| 7 | Select tournament sponsors |  | 1d | 2016-03-03 | 2016-03-08 | 6 | 0d |  | as late as possible |
| 8 | Solicit celebrity appearances |  | 3w | 2016-03-08 | 2016-05-03 | 2, 6, 7 | 0d |  | as late as possible |
| 9 | Schedule celebrity appearances |  | 1w | 2016-05-03 | 2016-05-19 | 8 | 0d |  | as late as possible |
| 10 | Design tournament logo |  | 1d | 2016-02-18 | 2016-02-19 | 1, 3 | 24d | 0d |  |
| 11 | Create tournament website |  | 2w | 2016-02-18 | 2016-03-23 | 10SS | 24d | 0d |  |
| 12 | Begin online registrations | milestone | 0d | 2016-03-23 | 2016-03-23 | 11 | 24d |  |  |
| 13 | Create volunteer list |  | 4h | 2016-05-19 | 2016-05-20 | 9, 8SS | 8.25d |  |  |
| 14 | Sign volunteer contract agreements |  | 1h | 2016-06-01 | 2016-06-01 |  | 22.38d | 0d | finish no later than 2016-06-01 |

Notes:
- 6: Contact local sporting goods stores for a list of potential sponsors.
